# 3GPP_Release-2000

Schedule from MS Project, 2000-01-03 to 2009-03-30, A marks actual dates.

## Calendars

- Standard: Mon-Fri 08:00-12:00, 13:00-17:00; Sat-Sun off.

## Resources

| Resource |
| --- |
| NP |
| N1 |
| N2 |
| N3 |
| N4 |
| N5 |
| TP |
| T1 |
| T2 |
| T3 |
| RP |
| R1 |
| R2 |
| R3 |
| R4 |
| SP |
| S1 |
| S2 |
| S3 |
| S4 |
| S5 |
| PCG |
| GP |
| No |
| CN4 |
| ? |
| WG G2 |
| G2 |
| G1 |
| G4 |
| G3 |
| All |
| Generic |
| MLST |
| G5 |
| S3; G2 |
| WG T2 |
| GP;G1 |
| G4;G5 |
| OMA |
| GP-G2 |
| Yes |
| GP; |
| N4; |
| GP; N1 |
| CT5 |
| C5 |
| C1 |
| C4 |
| C3 |
| C6 |
| G1; |
| 4 |
| ct |
| c;s;r |
| CT;RAN;SA |
| G2, |
| G1; G3 |
| CT6 |
| CT1 |
| CT1, CT3, CT4 |
| C1, C3, C4 |
| CP |
| R5 |

## Schedule

| ID | WBS | Task | Duration | Start | Finish | Complete | Remaining | Baseline start | Baseline finish | Baseline duration | Total slack | Constraint | Resources | Work | Actual work | Text9 | Text6 | Text1 | Text4 | Text8 | Text3 | Text5 |
| --- | --- | --- | --- | --- | --- | --- | --- | --- | --- | --- | --- | --- | --- | --- | --- | --- | --- | --- | --- | --- | --- | --- |
| 1 | 1 | VERSION 2007 September 12th | 1d | 2000-01-03 | 2000-01-03 |  |  | 2000-01-03 | 2000-01-03 | 1d | 2410d |  |  |  |  | 2044 |  |  |  |  |  |  |
| 2 | 2 | "CTRL + a" to display all the 3GPP fields | 1d | 2000-01-03 | 2000-01-03 |  |  | 2000-01-03 | 2000-01-03 | 1d | 2335d |  |  |  |  | 1462 |  |  |  |  |  |  |
| 3 | 3 | Content of Rel-8 (not frozen) | 1d | 2000-01-03 | 2000-01-03 |  |  | 2000-01-03 | 2000-01-03 | 1d | 2335d |  |  |  |  | 2058 |  |  |  |  |  |  |
| 5 | 4 | Release 8 Features | 1d? | 2000-01-03 | 2000-01-03 |  |  | 2000-01-03 | 2000-01-03 | 1d? | 2335d |  | CT;RAN;SA | 8h |  |  | Rel-8 |  |  |  |  |  |
| 6 | 5 | **3G Long Term Evolution** | 376d? | 2006-09-25 A | 2008-03-03 | 27% | 275.39d? | 2006-09-25 | 2008-03-03 | 376d? | 280d |  | RP | 14984h | 3531.6h |  | Rel-8 | LTE | Takehiro Nakamura (NTT DoCoMo) | MCC_RAN |  |  |
| 7 | 5.1 | LTE – Physical Layer | 255d? | 2006-09-25 A | 2007-09-14 | 65% | 89.25d? | 2006-09-25 | 2007-09-14 | 255d? | 401d | finish no earlier than 2007-09-14 | R1 | 2040h | 1326h |  | Rel-8 | LTE-Phys | Sadayuki Abeta, NTT DoCoMo | MCC_RAN | 36.2xy |  |
| 8 | 5.2 | LTE – Radio Interface Layer 2 and 3 Protocol Aspect | 255d? | 2006-09-25 A | 2007-09-14 | 20% | 204d? | 2006-09-25 | 2007-09-14 | 255d? | 401d | finish no earlier than 2007-09-14 | R2 | 2040h | 408h |  | Rel-8 | LTE-L23 | Benoist Sebire, Nokia | MCC_RAN | 36.3xy |  |
| 9 | 5.3 | LTE – eUTRAN Interfaces | 255d? | 2006-09-25 A | 2007-09-14 | 20% | 204d? | 2006-09-25 | 2007-09-14 | 255d? | 401d | finish no earlier than 2007-09-14 | R3 | 2040h | 408h |  | Rel-8 | LTE-interfaces | Mattias Wahlqvist, Ericsson | MCC_RAN | 36.4xy |  |
| 10 | 5.4 | LTE – RF Radio Transmission/Reception, System Performance Requirements and Conformance Testing | 320d? | 2006-09-25 A | 2007-12-14 | 40% | 192d? | 2006-09-25 | 2007-12-14 | 320d? | 336d | finish no earlier than 2007-12-14 | R4 | 2560h | 1024h |  | Rel-8 | LTE-RF | Frank Lamprecht, Siemens | MCC_RAN | 36.1xy |  |
| 11 | 5.5 | **LTE – Terminal Conformance Test Specifications** | 197d? | 2007-06-01 | 2008-03-03 |  |  | 2007-06-01 | 2008-03-03 | 197d? | 280d |  | R5 | 3296h |  |  | Rel-8 | LTE-UEConTest | Catherine Salinoc, NEC | MCC_RAN |  | catherine.salinoc@nectech.fr |
| 12 | 5.5.1 | 3G Long Term Evolution – Terminal Protocol Conformance Test Specifications | 197d? | 2007-06-01 | 2008-03-03 |  |  | 2007-06-01 | 2008-03-03 | 197d? | 280d | start no earlier than 2007-06-01 | R5 | 1576h |  |  | Rel-8 | LTE-UEConTest_SIG | Catherine Salinoc (NEC), Jacob John (Motorola) | Stoyan Baev | TS 36.508, 36.523-1, 36.523-2, 36.523-3 | catherine.salinoc@nectech.fr, Jacob.John@motorola.com |
| 13 | 5.5.2 | 3G Long Term Evolution – Terminal Radio Transmission and Reception Conformance Test Specifications | 197d? | 2007-06-01 | 2008-03-03 |  |  | 2007-06-01 | 2008-03-03 | 197d? | 280d | start no earlier than 2007-06-01 | R5 | 1576h |  |  | Rel-8 | LTE-UEConTest_RF | Catherine Salinoc, NEC | Stoyan Baev | TS 36.508, 36.521-1, 36.521-2 | catherine.salinoc@nectech.fr |
| 14 | 6 | **3GPP System Architecture Evolution Specification** | 532d? | 2006-06-08 A | 2008-06-20 | 18% | 435.97d? | 2006-06-08 | 2008-03-14 | 462d? | 201d |  | S2 | 101520h | 16891.6h |  | Rel-8 | SAES | Osok Song (Samsung) | Maurice | 23.228, 23.279 | osok.song@samsung.com |
| 15 | 6.1 | Requirements for evolution of the 3GPP system architecture | 157d? | 2006-06-08 A | 2007-01-12 | 95% | 7.85d? | 2006-06-08 | 2007-01-12 | 157d? | 576d | finish no earlier than 2007-01-12 | S1 | 1256h | 1193.2h |  | Rel-8 | AIPN-SAE | Michael Kurz (T-Mobile International) | Alain | 22.278 | michael.kurz@t-mobile.at |
| 16 | 6.2 | **SA aspects of System Architecture Evolution** | 384d? | 2007-01-02 A | 2008-06-20 | 40% | 230.91d? | 2007-01-02 | 2007-12-03 | 240d? | 201d |  | S2 | 33160h | 11366.4h |  | Rel-8 | SAES-SA |  |  |  |  |
| 17 | 6.2.1 | High level functions (common high level functions for all accesses) | 179d? | 2007-01-02 A | 2007-09-07 | 90% | 17.9d? | 2007-01-02 | 2007-09-07 | 179d? | 406d | finish no earlier than 2007-09-07 | S2 | 1432h | 1288.8h |  | Rel-8 | SAES-SA-HLF |  |  |  |  |
| 18 | 6.2.2 | **Functions and procedures for SAE to support LTE access** | 240d? | 2007-01-02 A | 2007-12-03 | 61% | 94.8d? | 2007-01-02 | 2007-12-03 | 240d? | 345d |  | S2 | 5760h | 2967.6h |  | Rel-8 | SAES-SA-FP_LTE |  |  |  |  |
| 19 | 7.2.2.1 | SAES-SA-FP_LTE with GTP variant | 240d? | 2007-01-02 A | 2007-12-03 | 66% | 81.6d? | 2007-01-02 | 2007-09-07 | 179d? | 345d | finish no earlier than 2007-12-03 | S2 | 1920h | 1267.2h |  | Rel-8 | SAES-SA-FP_LTE-GTP |  |  |  |  |
| 20 | 7.2.2.2 | SAES-SA-FP_LTE with IETF variant | 240d? | 2007-01-02 A | 2007-12-03 | 55% | 108d? | 2007-01-02 | 2007-12-03 | 240d? | 345d | finish no earlier than 2007-12-01 | S2 | 1920h | 1056h |  | Rel-8 | SAES-SA-FP_LTE-IETF |  |  |  |  |
| 21 | 6.2.3 | Functions and procedures for SAE to support 3GPP accesses (LTE <-> 2G/3G) | 240d? | 2007-01-02 A | 2007-12-03 | 75% | 60d? | 2007-01-02 | 2007-09-07 | 179d? | 345d | finish no earlier than 2007-12-03 | S2 | 1920h | 1440h |  | Rel-8 | SAES-SA-FP_3GPP |  |  |  |  |
| 22 | 6.2.4 | **Functions and procedures for SAE to support non-3GPP accesses** | 309d? | 2007-01-02 A | 2008-03-07 | 49% | 157.23d? | 2007-01-02 | 2007-12-03 | 240d? | 276d |  | S2 | 9272h | 3818h |  | Rel-8 | SAES-SA-FP_n3GPP |  |  |  |  |
| 23 | 7.2.4.1 | SAES-SA-FP_n3GPP Host-based Mobility aspects | 240d? | 2007-01-02 A | 2007-12-03 | 60% | 96d? | 2007-01-02 | 2007-09-07 | 179d? | 345d | finish no earlier than 2007-12-03 | S2 | 1920h | 1152h |  | Rel-8 | SAES-SA-FP_n3GPP-HBMob |  |  |  |  |
| 24 | 7.2.4.2 | SAES-SA-FP_n3GPP Network-based Mobility aspects | 240d? | 2007-01-02 A | 2007-12-03 | 60% | 96d? | 2007-01-02 | 2007-12-03 | 240d? | 345d | finish no earlier than 2007-12-01 | S2 | 1920h | 1152h |  | Rel-8 | SAES-SA-FP_n3GPP-NBMob |  |  |  |  |
| 25 | 6.2.4.3 | SAES-SA-FP_n3GPP Optimised Handover with CDMA | 185d? | 2007-06-25 A | 2008-03-07 | 35% | 120.25d? | 2007-01-02 | 2007-12-03 | 240d? | 276d | finish no earlier than 2008-03-07 | S2 | 1480h | 518h |  | Rel-8 | SAES-SA-FP_n3GPP-OptCDMA |  |  |  |  |
| 26 | 6.2.4.4 | SAES-SA-FP_n3GPP Optimised Handover with WiMAX | 185d? | 2007-06-25 A | 2008-03-07 | 35% | 120.25d? | 2007-01-02 | 2007-12-03 | 240d? | 276d | finish no earlier than 2008-03-07 | S2 | 1480h | 518h |  | Rel-8 | SAES-SA-FP_n3GPP-OptWIMAX |  |  |  |  |
| 27 | 6.2.5 | Functions and procedures for SAE to support LTE MBMS | 255d? | 2007-06-25 A | 2008-06-13 | 15% | 216.75d? | 2007-06-25 | 2007-11-30 | 115d? | 206d | finish no earlier than 2008-06-13 | S2 | 2040h | 306h |  | Rel-8 | SAES-SA-FP_LTEMBMS |  |  |  |  |
| 28 | 6.2.6 | Functions and procedures for SAE to support LCS | 220d? | 2007-08-13 A | 2008-06-13 | 5% | 209d? | 2007-08-13 | 2007-11-30 | 80d? | 206d | finish no earlier than 2008-06-13 | S2 | 1760h | 88h |  | Rel-8 | SAES-SA-FP_LCS |  |  |  |  |
| 29 | 6.2.7 | Single Radio Voice Call Continuity for 3GPP | 309d? | 2007-01-02 A | 2008-03-07 | 25% | 231.75d? | 2007-01-02 | 2007-12-01 | 239d? | 276d | finish no earlier than 2008-03-07 | S2 | 2472h | 618h |  | Rel-8 | SAES-SA-SR_VCC_3G |  |  |  |  |
| 30 | 6.2.8 | Voice Call Continuity for CDMA2000 1X | 185d? | 2007-06-25 A | 2008-03-07 | 15% | 157.25d? | 2007-01-02 | 2007-12-01 | 239d? | 276d | finish no earlier than 2008-03-07 | S2 | 1480h | 222h |  | Rel-8 | SAES-SA-VCC_1X |  |  |  |  |
| 31 | 6.2.9 | SAE impacts on IMS | 309d? | 2007-01-02 A | 2008-03-07 | 25% | 231.75d? | 2007-01-02 | 2007-12-01 | 239d? | 276d | finish no earlier than 2008-03-07 | S2 | 2472h | 618h |  | Rel-8 | SAES-SA-on_IMS |  |  |  |  |
| 32 | 6.2.10 | SAE aspects of Emergency Calls | 185d? | 2007-10-08 | 2008-06-20 |  |  | 2007-08-13 | 2007-11-30 | 80d? | 201d | start no earlier than 2007-10-08 | S2 | 1480h |  |  | Rel-8 | SAES-SA-EmCall |  |  |  |  |

Notes:
- 11: BB place holder for a number of RAN5 Tasks
- 12: Dependent on RAN as well as on CT/SA WIs
- 14: S2#52: Specification phase created. New WID approved SA#32
- 15: Moved to SA2 at SA#32
- 16: S2 internal target is September 2007
- 28: SA2 need RAN outputs (RAN dependencies)
- 32: Progress expected S2#60

| ID | WBS | Task | Type | Duration | Start | Finish | Complete | Remaining | Baseline start | Baseline finish | Baseline duration | Total slack | Constraint | Resources | Work | Actual work | Text1 | Text5 | Text6 | Text8 | Text12 |
| --- | --- | --- | --- | --- | --- | --- | --- | --- | --- | --- | --- | --- | --- | --- | --- | --- | --- | --- | --- | --- | --- |
| 33 | 6.3 | **CT aspects of System Architecture Evolution** |  | 290d? | 2007-02-05 A | 2008-03-14 | 5% | 274.23d? | 2007-02-05 | 2008-03-14 | 290d? | 271d |  | CP | 57360h | 3006.2h | SAES-St3 | hannu.hietalahti@nokia.com | Rel-8 | Andrijana, Seung Don, Kimmo |  |
| 34 | 6.3.1 | **CT1 aspects of SAES** |  | 290d? | 2007-02-05 A | 2008-03-14 | 5% | 275.5d? | 2007-02-05 | 2008-03-14 | 290d? | 271d |  | C1 | 20880h | 1044h | SAES-St3 |  | Rel-8 |  |  |
| 35 | 6.3.1.1 | Network selection procedures |  | 290d? | 2007-02-05 | 2008-03-14 |  |  | 2007-02-05 | 2008-03-14 | 290d? | 271d | start no earlier than 2007-02-05 | C1 | 2320h |  | SAES-St3-netsel |  | Rel-8 |  |  |
| 36 | 6.3.1.2 | UE NAS mobility procedures in idle and active mode |  | 290d? | 2007-02-05 A | 2008-03-14 | 8% | 266.8d? | 2007-02-05 | 2008-03-14 | 290d? | 271d | start no earlier than 2007-02-05 | C1 | 2320h | 185.6h | SAES-St3-NASmob |  | Rel-8 |  |  |
| 37 | 6.3.1.3 | Session management, bearer control and QoS aspects |  | 290d? | 2007-02-05 A | 2008-03-14 | 8% | 266.8d? | 2007-02-05 | 2008-03-14 | 290d? | 271d | start no earlier than 2007-02-05 | C1 | 2320h | 185.6h | SAES-St3-BCQOS |  | Rel-8 |  |  |
| 38 | 6.3.1.4 | Access to the EPC via non-3GPP access networks |  | 290d? | 2007-02-05 A | 2008-03-14 | 4% | 278.4d? |  |  |  | 271d | start no earlier than 2007-02-05 | C1 | 2320h | 92.8h | SAES-St3-non-3GPP |  | Rel-8 |  |  |
| 39 | 6.3.1.5 | Mobility management based on mobile IP |  | 290d? | 2007-02-05 A | 2008-03-14 | 8% | 266.8d? |  |  |  | 271d | start no earlier than 2007-02-05 | C1 | 2320h | 185.6h | SAES-St3-CT1MIP |  | Rel-8 |  |  |
| 40 | 6.3.1.6 | Inter-system mobility between E-UTRAN and other access networks |  | 290d? | 2007-02-05 | 2008-03-14 |  |  |  |  |  | 271d | start no earlier than 2007-02-05 | C1 | 2320h |  | SAES-St3-intersys |  | Rel-8 |  |  |
| 41 | 6.3.1.7 | CT1 SAE impact on services, network functions and capabilities |  | 290d? | 2007-02-05 A | 2008-03-14 | 4% | 278.4d? | 2007-02-05 | 2008-03-14 | 290d? | 271d | start no earlier than 2007-02-05 | C1 | 2320h | 92.8h | SAES-St3-CT1imp |  | Rel-8 |  |  |
| 42 | 6.3.1.8 | Deleted - Interoperability | milestone | 0d? | 2008-03-14 A | 2008-03-14 A | 100% |  | 2007-02-05 | 2008-03-14 | 290d? |  | start no earlier than 2008-03-14 | C1 |  |  | SAES-St3-interop |  | Rel-8 |  |  |
| 43 | 6.3.1.9 | CT1 security aspects |  | 290d? | 2007-02-05 A | 2008-03-14 | 8% | 266.8d? | 2007-02-05 | 2008-03-14 | 290d? | 271d | start no earlier than 2007-02-05 | C1 | 2320h | 185.6h | SAES-St3-CT1sec |  | Rel-8 |  |  |
| 44 | 6.3.2 | **CT3 aspects of SAES** |  | 290d? | 2007-02-05 | 2008-03-14 |  |  | 2007-02-05 | 2008-03-14 | 290d? | 271d |  | C3 | 11600h |  | SAES-St3 |  | Rel-8 |  |  |
| 45 | 6.3.2.1 | PCC aspects of SAE |  | 290d? | 2007-02-05 | 2008-03-14 |  |  | 2007-02-05 | 2008-03-14 | 290d? | 271d | start no earlier than 2007-02-05 | C3 | 2320h |  | SAES-St3-PCC |  | Rel-8 |  |  |
| 46 | 6.3.2.2 | Interworking between EPC and external PDNs |  | 290d? | 2007-02-05 | 2008-03-14 |  |  | 2007-02-05 | 2008-03-14 | 290d? | 271d | start no earlier than 2007-02-05 | C3 | 2320h |  | SAES-St3-intwk |  | Rel-8 |  |  |
| 47 | 6.3.2.3 | QoS mechanisms |  | 290d? | 2007-02-05 | 2008-03-14 |  |  | 2007-02-05 | 2008-03-14 | 290d? | 271d | start no earlier than 2007-02-05 | C3 | 2320h |  | SAES-St3-QoS |  | Rel-8 |  |  |
| 48 | 6.3.2.4 | CT3 SAE impact on existing capabilities |  | 290d? | 2007-02-05 | 2008-03-14 |  |  | 2007-02-05 | 2008-03-14 | 290d? | 271d | start no earlier than 2007-02-05 | C3 | 2320h |  | SAES-St3-CT3imp |  | Rel-8 |  |  |
| 49 | 6.3.3 | **CT4 aspects of SAES** |  | 215d? | 2007-02-05 A | 2007-11-30 | 10% | 193.5d? | 2007-02-05 | 2008-03-14 | 290d? | 346d |  | C4 | 18920h | 1836h | SAES-St3 |  | Rel-8 |  |  |
| 50 | 6.3.3.1 | EPC - HSS interface |  | 215d? | 2007-02-05 A | 2007-11-30 | 10% | 193.5d? | 2007-02-05 | 2008-03-14 | 290d? | 346d | finish no earlier than 2007-11-30 | C4 | 1720h | 172h | SAES-St3-EPC_HSS |  | Rel-8 |  |  |
| 51 | 6.3.3.2 | Within EPC |  | 215d? | 2007-02-05 A | 2007-11-30 | 10% | 193.5d? | 2007-02-05 | 2008-03-14 | 290d? | 346d | finish no earlier than 2007-11-30 | C4 | 1720h | 172h | SAES-St3-EPC |  | Rel-8 |  |  |
| 52 | 6.3.3.3 | EPC - GPRS |  | 215d? | 2007-02-05 A | 2007-11-30 | 10% | 193.5d? | 2007-02-05 | 2008-03-14 | 290d? | 346d | finish no earlier than 2007-11-30 | C4 | 1720h | 172h | SAES-St3-EPC_GPRS |  | Rel-8 |  |  |
| 53 | 6.3.3.4 | EPC - non-3GPP IP access |  | 215d? | 2007-02-05 A | 2007-11-30 | 10% | 193.5d? | 2007-02-05 | 2008-03-14 | 290d? | 346d | finish no earlier than 2007-11-30 | C4 | 1720h | 172h | SAES-St3-EPC_n3G |  | Rel-8 |  |  |
| 54 | 6.3.3.5 | AAA/HSS related |  | 215d? | 2007-02-05 A | 2007-11-30 | 10% | 193.5d? | 2007-02-05 | 2008-03-14 | 290d? | 346d | finish no earlier than 2007-11-30 | C4 | 1720h | 172h | SAES-St3-AAA_HSS |  | Rel-8 |  |  |
| 55 | 6.3.3.6 | EPC - AAA interface |  | 215d? | 2007-02-05 A | 2007-11-30 | 10% | 193.5d? | 2007-02-05 | 2008-03-14 | 290d? | 346d | finish no earlier than 2007-11-30 | C4 | 1720h | 172h | SAES-St3-EPC_AAA |  | Rel-8 |  |  |
| 56 | 6.3.3.7 | EPC - EPC |  | 215d? | 2007-02-05 A | 2007-11-30 | 10% | 193.5d? | 2007-02-05 | 2008-03-14 | 290d? | 346d | finish no earlier than 2007-11-30 | C4 | 1720h | 172h | SAES-St3-EPC_EPC |  | Rel-8 |  |  |
| 57 | 6.3.3.8 | SAE / LTE identities |  | 215d? | 2007-02-05 A | 2007-11-30 | 10% | 193.5d? | 2007-02-05 | 2008-03-14 | 290d? | 346d | finish no earlier than 2007-11-30 | C4 | 1720h | 172h | SAES-St3-IDs |  | Rel-8 |  |  |
| 58 | 6.3.3.9 | MME - SGSN "signalling free" protocol |  | 215d? | 2007-02-05 A | 2007-11-30 | 10% | 193.5d? | 2007-02-05 | 2008-03-14 | 290d? | 346d | finish no earlier than 2007-11-30 | C4 | 1720h | 172h | SAES-St3-MME_SGSN |  | Rel-8 |  |  |
| 59 | 6.3.3.10 | CT4 SAE impact on existing capabilities |  | 215d? | 2007-02-05 A | 2007-11-30 | 10% | 193.5d? | 2007-02-05 | 2008-03-14 | 290d? | 346d | finish no earlier than 2007-11-30 | C4 | 1720h | 172h | SAES-St3-impacts |  | Rel-8 |  |  |
| 60 | 6.3.4 | Deleted - UE to EPC NAS signalling (incl. MBMS and QoS aspects) |  | 290d? | 2007-02-05 | 2008-03-14 |  |  | 2007-02-05 | 2008-03-14 | 290d? | 271d | start no earlier than 2007-02-05 | C1 | 2320h |  | SAES-St3-sig |  | Rel-8 |  |  |
| 61 | 6.3.5 | Deleted -User and Control plane protocols |  | 165d? | 2007-02-05 | 2007-09-21 |  |  | 2007-02-05 | 2007-09-21 | 165d? | 396d | finish no earlier than 2007-09-21 | C4 | 1320h |  | SAES-St3-prot |  | Rel-8 |  |  |
| 62 | 6.4 | Deleted - GPRS enhancements for LTE access |  | 198d? | 2006-12-01 A | 2007-09-04 | 15% | 168.3d? | 2006-12-01 | 2007-09-04 | 198d? | 409d | start no earlier than 2006-12-01 | S2 | 1584h | 237.6h | SAES-GPRS_LTE | chris.pudney@vodafone.com | Rel-8 | Maurice |  |
| 63 | 6.5 | Deleted - Architecture enhancements for non-3GPP accesses |  | 198d? | 2006-12-01 A | 2007-09-04 | 15% | 168.3d? | 2006-12-01 | 2007-09-04 | 198d? | 409d | start no earlier than 2006-12-01 | S2 | 1584h | 237.6h | SAES-non_3GPP | Irfan.Ali@motorola.com | Rel-8 | Maurice |  |
| 64 | 6.6 | Deleted: Stage 2 of architecture for the 3GPP System Architecture Evolution |  | 290d? | 2007-02-05 A | 2008-03-14 | 4% | 279.7d? | 2007-02-05 | 2008-03-14 | 290d? | 271d |  | S2 | 2320h | 82.4h | SAES-St2 | chris.pudney@vodafone.com | Rel-8 | Maurice | SP-34 |
| 65 | 7 | GERAN support for GERAN - 3G Long Term Evolution interworking |  | 381d? | 2006-09-08 A | 2008-02-22 | 25% | 285.75d? | 2006-09-08 | 2008-02-15 | 376d? | 286d | finish no earlier than 2008-02-22 | GP | 3048h | 762h | GELTE | sergio.parolari@nsn.com, vlora.rexhepi@nokia.com | Rel-8 | Paolo |  |

Notes:
- 33: CT wide WID approved ib CT#34 / Text3: 24.8yz, 29.8ab, 29.8cd / Text4: Hannu Hietalahti, Nokia
- 46: 08/03/2007 08:00
- 47: 08/03/2007 08:00
- 48: 08/03/2007 08:00
- 49: Text3: 29.803
- 62: SP-34: GPRS enhancements for LTE access item created. / Text3: 23.401 / Text4: Chris Pudney (Vodafone)
- 63: SP-34: Architecture enhancements for non-3GPP accesses item created. / Text3: 23.402 / Text4: Irfan Ali (Motorola)
- 64: THIS LINE IS DELETED, replaced by the 2 Architecture parallel tracks. / Text3: 23.002, 23.060, 23.107, 23.203, 23.228, 23.234, 23.246, 23.271, 23.279 / Text4: Chris Pudney (Vodafone)
- 65: Text3: 24.008, 43.055, 43.129, 43.246, 44.018, 44.060, 45.002, 45.008, 45.010, 48.008,48.018, 51.010 / Text4: Vlora Rexhepi - van der Pol, Nokia Corporation, / Sergio Parolari, Nokia Siemens Networks S.p.A.

| ID | WBS | Task | Type | Duration | Start | Finish | Complete | Remaining | Baseline start | Baseline finish | Baseline duration | Total slack | Constraint | Resources | Work | Actual work | Text1 | Text4 | Text6 | Text3 | Text5 | Text8 | Text7 |
| --- | --- | --- | --- | --- | --- | --- | --- | --- | --- | --- | --- | --- | --- | --- | --- | --- | --- | --- | --- | --- | --- | --- | --- |
| 66 | 8 | **Contact Manager for 3GPP UICC applications** |  | 447d? | 2006-06-22 A | 2008-03-07 | 2% | 436.3d? | 2006-06-22 | 2008-03-07 | 447d? | 276d |  | C6 | 6952h | 80.8h | eUPHBOOK | Claus Dietze (Giesecke & Devrient) | Rel-8 |  |  |  |  |
| 67 | 8.1 | Requirements for Contact Manager |  | 202d? | 2006-06-22 A | 2007-03-30 | 5% | 191.9d? | 2006-06-22 | 2007-03-30 | 202d? | 521d | finish no earlier than 2007-03-30 | C6 | 1616h | 80.8h | eUPHBOOK-St1 | Claus Dietze (Giesecke & Devrient) | Rel-8 | 21.111 |  |  |  |
| 68 | 8.2 | Specification of technical solution for the enhanced phonebook |  | 220d? | 2007-05-07 | 2008-03-07 |  |  | 2007-05-07 | 2008-03-07 | 220d? | 276d | finish no earlier than 2008-03-07 | C6 | 1760h |  | eUPHBOOK-Spec | Claus Dietze (Giesecke & Devrient) | Rel-8 | 31.xyz |  |  |  |
| 69 | 8.3 | Deleted - Implementation of eUPHBOOK | milestone | 0d? | 2007-06-21 | 2007-06-21 |  |  | 2007-06-21 | 2007-06-21 | 0d? | 462d | start no earlier than 2007-06-21 | C6 |  |  | eUPHBOOK-St23 |  | Rel-8 | 31.102 |  |  |  |
| 70 | 9 | **Enhancements for VGCS Applications** |  | 508d? | 2006-03-15 A | 2008-02-22 | 66% | 171.53d? | 2006-03-15 | 2007-11-16 | 438d? | 286d |  | S1 | 13296h | 6267.6h | EVA | Amar Deol, Nortel Networks | Rel-8 | 42.068 | deola@nortel.com | Alain |  |
| 71 | 9.1 | SA1 aspects for EVA |  | 191d? | 2006-03-15 A | 2006-12-06 A | 100% |  | 2006-03-15 | 2006-12-06 | 191d? |  | finish no earlier than 2006-12-06 | S1 | 1528h | 1528h | EVA-s1 | Amar Deol, Nortel Networks | Rel-8 | 42.068 | deola@nortel.com | Alain |  |
| 72 | 9.2 | C1 aspects for EVA |  | 271d? | 2006-06-02 A | 2007-06-15 | 55% | 121.95d? | 2006-06-02 | 2007-06-15 | 271d? | 466d | finish no earlier than 2007-06-15 | C1 | 2168h | 1192.4h | EVA | Milan Patel | Rel-8 | 43.068, 44.068 | milanpa@nortel.com | Andrijana |  |
| 73 | 9.3 | C4 aspects for EVA |  | 261d? | 2006-06-02 A | 2007-06-01 | 80% | 52.2d? | 2006-06-02 | 2007-06-01 | 261d? | 476d | finish no earlier than 2007-06-01 | C4 | 2088h | 1670.4h | EVA-c4 |  | Rel-8 | 29.002 |  | Kimmo |  |
| 74 | 9.4 | GERAN2 Aspects of EVA |  | 431d? | 2006-06-30 A | 2008-02-22 | 50% | 215.5d? | 2006-06-30 | 2007-11-16 | 361d? | 286d | finish no earlier than 2008-02-22 | G2 | 3448h | 1724h | EVA-EVGCSA | Frank Billenkamp (Nortel Networks) | Rel-8 | 44.018, 48.008 | frank.billenkamp@nortel.com | Gert |  |
| 75 | 10 | **IMS Service Brokering enhancements** |  | 69d? | 2005-12-07 A | 2006-03-13 A | 100% |  | 2005-12-07 | 2006-03-13 | 69d? |  |  | S1 | 1104h | 1104h | ISB | John-Luc Bakker (Telcordia) | Rel-8 | 22.228 | jbakker@telcordia.com | Alain |  |
| 76 | 10.1 | Stage 1 of ISB |  | 69d? | 2005-12-07 A | 2006-03-13 A | 100% |  | 2005-12-07 | 2006-03-13 | 69d? |  | finish no earlier than 2006-03-13 | S1 | 552h | 552h | ISB-s1 | John-Luc Bakker (Telcordia) | Rel-8 | 22.228 | jbakker@telcordia.com | Alain |  |
| 77 | 11 | **Multimedia Priority Service** |  | 462d? | 2006-06-08 A | 2008-03-14 | 65% | 161.7d? | 2006-06-08 | 2007-09-21 | 337d? | 271d |  | S1 | 9072h | 4838.4h | PRIOR | Jim Garrahan (Telcordia) | Rel-8 | 22.153 | jgarraha@telcordia.com | Alain |  |
| 78 | 11.1 | Service Requirements for PRIOR |  | 336d? | 2006-06-08 A | 2007-09-20 | 80% | 67.2d? | 2006-06-08 | 2007-09-20 | 336d? | 397d | finish no earlier than 2007-09-20 | S1 | 2688h | 2150.4h | PRIOR-EMR | Jim Garrahan (Telcordia) | Rel-8 | 22.153 | jgarraha@telcordia.com | Alain |  |
| 79 | 11.2 | Multimedia Priority Service for PRIOR - Stage 3 |  | 336d? | 2006-12-01 A | 2008-03-14 | 50% | 168d? | 2006-12-01 | 2007-09-21 | 211d? | 271d | finish no earlier than 2008-03-14 | C1 | 2688h | 1344h | PRIOR-MM | Keith Drage, Alcatel-Lucent | Rel-8 | 24.229 | drage@Alcatel-Lucent.com | Andrijana |  |
| 80 | 12 | eCall Data Transfer – Requirements |  | 51d? | 2006-09-28 A | 2006-12-07 A | 100% |  | 2006-09-28 | 2006-12-07 | 51d? |  | finish no earlier than 2006-12-07 | S1 | 408h | 408h | EData | Rhys Robinson (Airbiquity) | Rel-8 | 22.101, 22.105 | rrobinson@airbiquity.com | Alain |  |
| 81 | 13 | Local Charging Zone Requirements |  | 51d? | 2006-09-28 A | 2006-12-07 A | 100% |  | 2006-09-28 | 2006-12-07 | 51d? |  | finish no earlier than 2006-12-07 | S1 | 408h | 408h | LCZR | Hong Liu (China Mobile) | Rel-8 | 22.115 | liuhongyfw@chinamobile.com | Alain |  |
| 82 | 14 | Enhancements to BS30 Bearer service for Videotelephony |  | 51d? | 2007-01-04 A | 2007-03-15 | 10% | 45.9d? | 2007-01-04 | 2007-03-15 | 51d? | 532d | finish no earlier than 2007-03-15 | S1 | 408h | 40.8h | BS30 | Andre Jarvis (3) | Rel-8 | 22.002, 22.004, 22.101, 22.105, 24.008 | andre.jarvis@three.co.uk | Alain |  |
| 83 | 15 | Deleted (never approved) FBI Phase 2 |  | 349d? | 2006-06-30 | 2007-10-31 |  |  | 2006-06-30 | 2007-10-31 | 349d? | 368d | start no earlier than 2006-06-30 | S2 | 2792h |  | FBI2 |  | Rel-8 |  |  | Maurice | TSG |
| 84 | 16 | **System enhancements for interconnection interfaces between two IMSs** |  | 468d? | 2006-08-16 A | 2008-05-30 | 18% | 382.46d? | 2006-08-16 | 2008-05-30 | 468d? | 216d |  | S2 | 9760h | 1357.56h | IMS_NNI | Steve Tsang-Kwong-U, Orange | Rel-8 |  |  |  |  |
| 85 | 16.1 | Stage 2 of IMS_NNI |  | 131d? | 2007-06-22 A | 2007-12-21 | 60% | 52.4d? | 2007-06-22 | 2007-12-21 | 131d? | 331d | finish no earlier than 2007-12-21 | S2 | 1048h | 628.8h | IMS_NNI | Delphin Barankanira, Orange | Rel-8 |  |  |  |  |
| 86 | 16.2 | Protocol impact of FBI for TISPAN R2 |  | 152d? | 2006-08-16 | 2007-03-15 |  |  | 2006-08-16 | 2007-03-15 | 152d? | 532d | finish no earlier than 2007-03-15 | C1 | 1216h |  | FBI2-TISP2-c1 |  | Rel-8 |  |  |  |  |
| 87 | 16.3 | IMS inter-operator service interconnection interface |  | 261d? | 2007-06-01 | 2008-05-30 |  |  | 2007-06-01 | 2008-05-30 | 261d? | 216d | finish no earlier than 2008-05-30 | C3 | 2088h |  | FBI2-IOPSI | Mauro Ficaccio (Telecom Italia) | Rel-8 | 29.abc, 29.def | mauro.ficaccio@telecomitalia.it | Seung Don |  |
| 88 | 16.4 | Charging harmonization for NGN between 3GPP and ATIS-TMOC |  | 51d? | 2006-09-28 A | 2006-12-07 A | 100% |  | 2006-09-28 | 2006-12-07 | 51d? |  | finish no earlier than 2006-12-07 | S5 | 408h | 408h | FBI2-TISP2-CH | Amdocs | Rel-8 | 32.297 |  | Adrian |  |
| 89 | 16.5 | Deleted (never approved) - Stage 2 of FBI for TISPAN R2 - Rel 8 |  | 157d? | 2007-04-26 A | 2007-11-30 | 5% | 149.15d? | 2007-04-26 | 2007-11-30 | 157d? | 346d | start no earlier than 2007-04-26 | S2 | 1256h | 62.8h | FBI2-TISP2-s2 |  | Rel-8 |  |  |  |  |
| 90 | 17 | IMS System enhancements for corporate network access |  | 131d? | 2007-06-22 A | 2007-12-21 | 10% | 117.9d? | 2007-06-22 | 2007-12-21 | 131d? | 331d | finish no earlier than 2007-12-21 | S2 | 1048h | 104.8h | IMS_Corp | Delphin Barankanira, Orange | Rel-8 |  |  |  |  |

Notes:
- 66: Moved from Rel-7 to Rel-8 at CT#33. C6-43: WI Name change to Enhanced USIM Phonebook. Completion date updated to 03/2008. Supporting Members: Giesecke & Devrient, T-Mobile, SagemOrga, Oberthur, Gemalto, Telefonica, ST Incard, Microelectronica, Cingular, O
- 67: C6-43: Name Changed to Requirements for Contact Manager. Expected completion updated from CT#34 to CT#35.
- 68: New TS 31.xyz to be produced
- 73: CT4#32: Crs are presented and in principle agreed, waiting for the approval of stage2...
- 77: Created by MCC to group 320023 (Stage 1) and 340012 (Stage 3) wrongly shown as idependent Features
- 78: Official name is "Multimedia Priority Service" but this is identical to UID 31041
- 79: "CT1" corrected into "C1"
- 83: Added by MCC as a consequence of the move to Rel8 of TISPAN Rel-2 impacts on 3GPP
- 84: Name changed from "System enhancements for TISPAN Rel2" at SA36
- 87: Approved at CT#36
- 88: 09/2006 SA#33 WID approved
- 89: It might be more appropriate to introduce the individual functions instead of a global title. SA2 WID expected at SA#36

| ID | WBS | Task | Type | Duration | Start | Finish | Complete | Remaining | Baseline start | Baseline finish | Baseline duration | Total slack | Constraint | Resources | Work | Actual work | Text1 | Text6 | Text8 | Text3 | Text4 | Text5 |
| --- | --- | --- | --- | --- | --- | --- | --- | --- | --- | --- | --- | --- | --- | --- | --- | --- | --- | --- | --- | --- | --- | --- |
| 91 | 18 | **IMS Enhancements for support of Packet Cable access** |  | 272d? | 2006-12-06 A | 2007-12-20 | 41% | 160.18d? | 2006-12-06 | 2007-12-20 | 272d? | 332d |  | S2 | 18744h | 6481.42h | PktCbl | Rel-8 | Maurice |  |  |  |
| 92 | 18.1 | **IMS Enhancements for Security Requirements in Support of Cable Deployments** |  | 272d? | 2006-12-06 A | 2007-12-20 | 36% | 174.73d? | 2006-12-06 | 2007-12-20 | 272d? | 332d |  | S3 | 7232h | 1808h | PktCbl-Sec | Rel-8 | Dioniso | 33.203, 33.210, 33.220, 24.229 | Steve Dotson (Cablelabs) | s.dotson@cablelabs.com |
| 93 | 18.1.1 | S3 Aspects of PktCbl-Sec |  | 272d? | 2006-12-06 A | 2007-12-20 | 50% | 136d? | 2006-12-06 | 2007-12-20 | 272d? | 332d | finish no earlier than 2007-12-20 | S3 | 2176h | 1088h | PktCbl-Sec | Rel-8 | Dioniso | 33.203, 33.210, 33.220, 24.229 | Steve Dotson (Cablelabs) | s.dotson@cablelabs.com |
| 94 | 18.1.2 | CT1 Aspects of PktCbl-Sec |  | 180d? | 2007-03-26 A | 2007-11-30 | 40% | 108d? | 2007-03-26 | 2007-11-30 | 180d? | 346d | start no earlier than 2007-03-26 | C1 | 1440h | 576h | PktCbl-Sec | Rel-8 | Andrijana | 24.229, 24.109 | David Hancock (CableLabs) | D.Hancock@ CableLabs.com |
| 95 | 18.1.3 | CT4 Aspects of PktCbl-Sec |  | 180d? | 2007-03-26 A | 2007-11-30 | 10% | 162d? | 2007-03-26 | 2007-11-30 | 180d? | 346d | start no earlier than 2007-03-26 | C4 | 1440h | 144h | PktCbl-Sec | Rel-8 | Kimmo | 29.228, 29229, 23.008, | David Hancock (CableLabs) | D.Hancock@ CableLabs.com |
| 96 | 18.2 | **IMS Enhancements for Cable Client Types and Deployment Models** |  | 216d? | 2007-02-05 A | 2007-12-03 | 8% | 198.33d? | 2007-02-05 | 2007-11-30 | 215d? | 345d |  | S2 | 4896h | 461.55h | PktCbl-Deploy | Rel-8 |  |  |  |  |
| 97 | 18.2.1 | Architecture aspects of PktCbl-Deploy |  | 216d? | 2007-02-05 A | 2007-12-03 | 15% | 183.6d? | 2007-02-05 | 2007-09-14 | 160d? | 345d | finish no earlier than 2007-12-03 | S2 | 1728h | 259.2h | PktCbl-Deploy | Rel-8 |  |  |  |  |
| 98 | 18.2.2 | CT1 aspects of PktCbl-Deploy |  | 180d? | 2007-03-26 | 2007-11-30 |  |  | 2007-03-26 | 2007-11-30 | 180d? | 346d | start no earlier than 2007-03-26 | C1 | 1440h |  | PktCbl-Deploy | Rel-8 | Andrijana | 24.229, 24167 | David Hancock (CableLabs) | D.Hancock@ CableLabs.com |
| 99 | 18.3 | **IMS Inter-working Aspects in Support of Cable Regulatory requirements** |  | 215d? | 2007-02-05 A | 2007-11-30 | 89% | 22.76d? | 2007-02-05 | 2007-11-30 | 215d? | 346d |  | S2 | 4440h | 3317.29h | PktCbl-Intw | Rel-8 | Maurice | 23.228 | Bernie McKibben (CableLabs) | B.McKibben@CableLabs.com |
| 100 | 18.3.1 | Architecture aspects of PktCbl-Interwork |  | 160d? | 2007-02-05 A | 2007-09-14 A | 100% |  | 2007-02-05 | 2007-09-14 | 160d? |  | start no earlier than 2007-02-05 | S2 | 1280h | 1280h | PktCbl-Intw | Rel-8 | Maurice | 23.228 | Bernie McKibben (CableLabs) | B.McKibben@CableLabs.com |
| 101 | 18.3.2 | CT1 aspects of PktCbl-Interwork |  | 180d? | 2007-03-26 A | 2007-11-30 | 80% | 36d? | 2007-03-26 | 2007-11-30 | 180d? | 346d | start no earlier than 2007-03-26 | C1 | 1440h | 1152h | PktCbl-Intw | Rel-8 | Andrijana | 24.229 | David Hancock (CableLabs) | D.Hancock@ CableLabs.com |
| 102 | 19 | Services Alignment and Migration |  | 256d? | 2006-12-06 A | 2007-11-28 | 65% | 89.6d? | 2006-12-06 | 2007-11-28 | 256d? | 348d | finish no earlier than 2007-09-20 | S1 | 2048h | 1331.2h | ServAl | Rel-8 | Alain | 22.182 | Feng Lingjuan (China Mobile) | (fenglingjuan@chinamobile.com) |
| 103 | 20 | Support of Customised Alerting Tone Service |  | 207d? | 2006-12-06 A | 2007-09-20 | 80% | 41.4d? | 2006-12-06 | 2007-09-20 | 207d? | 397d | finish no earlier than 2007-09-20 | S1 | 1656h | 1324.8h | CusAlert | Rel-8 | Alain | 22.182 | Feng Lingjuan (China Mobile) | (fenglingjuan@chinamobile.com) |
| 104 | 21 | I-WLAN NSP |  | 6d? | 2006-12-06 A | 2006-12-13 | 70% | 1.8d? | 2006-12-06 | 2006-12-13 | 6d? | 598d | finish no earlier than 2006-12-13 | S1 | 48h | 33.6h | IWLANNSP | Rel-8 | Alain | 22.234 | Chris Friel (O2) | chris.friel@o2.com |
| 105 | 22 | **Support of Service-Level Interworking for Messaging Services** |  | 195d? | 2007-03-26 A | 2007-12-24 | 40% | 117d? | 2007-03-26 | 2007-12-24 | 195d? | 330d |  | S1 | 2944h | 1609.6h | MESSIW | Rel-8 | Alain | 22.105, 22.340, 23.abc, TS 23.xyz (TBD) | Liu Ling (Huawei); Duan Xiaoqin (Huawei) | ling.liu@huawei.com; duanxiaoqin@huawei.com |
| 106 | 22.1 | Stage 1 aspects of Service-Level Interworking for Messaging Services | milestone | 0d? | 2007-03-26 A | 2007-03-26 A | 100% |  | 2007-03-26 | 2007-03-26 | 0d? |  | finish no earlier than 2007-12-01 | S1 |  |  | MESSIW-St1 | Rel-8 | Alain | 22.105, 22.340 | Liu Ling (Huawei) | ling.liu@huawei.com |
| 107 | 22.2 | Stage 2 aspects of Service-Level Interworking for Messaging Services |  | 173d? | 2007-04-26 A | 2007-12-24 | 40% | 103.8d? | 2007-04-26 | 2007-12-24 | 173d? | 330d | finish no earlier than 2007-12-21 | S2 | 1384h | 553.6h | MESSIW-St2 | Rel-8 | Maurice | 22.105, 22.340, 23.811, TS 23.xyz (TBD) | Patrice Hede (Huawei) | patrice.hede@huawei.com |
| 108 | 23 | **OAM&P 8** |  | 857d? | 2005-09-02 A | 2008-12-15 | 24% | 652.84d? | 2005-09-02 | 2008-12-15 | 857d? | 75d |  | S5 | 32441.1h | 6514.4h | OAM8 | Rel-8 | Adrian |  |  |  |
| 109 | 23.1 | Telecom Management Methodology |  | 857d? | 2005-09-02 A | 2008-12-15 | 30% | 599.9d? | 2005-09-02 | 2008-12-15 | 857d? | 75d | finish no earlier than 2008-12-15 | S5 | 6856h | 2056.8h |  | Rel-8 | Adrian | TS 32.155, CR 32.150/1/2/3/4 | Ericsson |  |
| 110 | 23.2 | Advanced Alarming on Itf-N (Study + Implementation) |  | 596d? | 2005-09-02 A | 2007-12-14 | 30% | 417.2d? | 2005-09-02 | 2007-12-14 | 596d? | 336d | finish no earlier than 2007-12-14 | S5 | 4768h | 1430.4h |  | Rel-8 | Adrian | TS 32.121/2/3/5 | Nokia Siemens Networks |  |
| 111 | 23.3 | CN CS Bearer Transport Network (BTN) relative NRM |  | 596d? | 2005-09-02 A | 2007-12-14 | 20% | 476.8d? | 2005-09-02 | 2007-12-14 | 596d? | 336d | finish no earlier than 2007-12-14 | S5 | 4768h | 953.6h |  | Rel-8 | Adrian | CR 32.632/3/5 | China Mobile |  |
| 112 | 23.4 | IP bearer network Performance measurement definitions |  | 596d? | 2005-09-02 A | 2007-12-14 | 30% | 417.2d? | 2005-09-02 | 2007-12-14 | 596d? | 336d | finish no earlier than 2007-12-14 | S5 | 4768h | 1430.4h |  | Rel-8 | Adrian | CR 32.321/2/3/5 | China Mobile |  |
| 113 | 23.5 | HSUPA performance measurements |  | 196d? | 2007-06-07 A | 2008-03-06 | 20% | 156.8d? | 2007-06-07 | 2008-03-06 | 196d? | 277d | finish no earlier than 2008-03-06 | S5 | 1568h | 313.6h |  | Rel-8 |  | CR 32.405 | China Mobile |  |
| 114 | 23.6 | Key Performance Indicator (KPI) |  | 196d? | 2007-06-07 A | 2008-03-06 | 20% | 156.8d? | 2007-06-07 | 2008-03-06 | 196d? | 277d | finish no earlier than 2008-03-06 | S5 | 1568h | 313.6h |  | Rel-8 |  | TS 32.xyz | China Mobile |  |
| 115 | 23.7 | Service Level Tracing in IMS |  | 379.14d? | 2006-09-22 A | 2008-04-10 |  | 379.14d? | 2006-09-22 | 2008-04-10 | 379.14d? | 252.04d | finish no earlier than 2008-03-15 | C1 | 3033.12h |  | OAM7-Trace | Rel-8 | Andrijana | 24.229, 24.167, 29.228,29.229,29.163,29.332 | Jari Jansson, Nokia | jari.jansson@nokia.com |
| 116 | 23.8 | Deleted - Network Infrstructure Management 8 | milestone | 0d? | 2007-07-13 A | 2007-07-13 A | 100% |  |  |  |  |  | finish no earlier than 2007-07-13 | S5 |  |  |  | Rel-8 | Adrian |  |  |  |
| 117 | 23.9 | Deleted - Performance Management 8 |  | 1d? | 2007-07-13 A | 2007-07-13 A | 100% |  |  |  |  |  |  | S5 | 8h | 8h |  | Rel-8 | Adrian |  |  |  |
| 118 | 23.10 | Deleted - Trace Management 8 |  | 1d? | 2007-06-22 A | 2007-06-22 A | 100% |  | 2007-06-22 | 2007-06-22 | 1d? |  | start no earlier than 2007-06-22 | S5 | 8h | 8h |  | Rel-8 |  |  |  |  |
| 119 | 24 | Registration in Densely-populated area |  | 4d? | 2007-03-12 A | 2007-03-15 | 90% | 0.4d? | 2007-03-12 | 2007-03-15 | 4d? | 532d | start no earlier than 2007-03-12 | S1 | 32h | 28.8h | RED | Rel-8 | Alain | 22.101 | Tsuyoshi Takakura (NTT DoCoMo Inc.) | takakurat@s1.nttdocomo.co.jp |
| 120 | 25 | Lawful Interception in the 3GPP Rel-8 |  | 265d? | 2007-03-12 A | 2008-03-14 | 20% | 212d? | 2007-03-12 | 2008-03-14 | 265d? | 271d | finish no earlier than 2008-03-14 | S3 | 2120h | 424h | LI8 | Rel-8 | Dioniso | 33.106, 33.107, 33.108 | Berthold Wilhelm (BMWi/BNetzA) | berthold.wilhelm@bnetza.de |

Notes:
- 94: Supporting Companies:
- 95: Supporting Companies:
- 98: Supporting Companies:
- 99: Supporting Companies: CableLabs, Nortel, Cisco, Samsung, Alcatel-Lucent, Siemens, Motorola, Hewlett-Packard, Ericsson
- 100: Supporting Companies: CableLabs, Nortel, Cisco, Samsung, Alcatel-Lucent, Siemens, Motorola, Hewlett-Packard, Ericsson
- 101: Supporting Companies:
- 102: previous names were Services Alignment, Service Migration
- 105: WID updated by S2-57, Approved at SP-36
- 107: WID updated by S2-57, Approved at SP-36. Rapporteur updated S2#59
- 108: Created to encompass the Rel7 Work Tasks shifted to Rel8
- 109: Request to TSG#35 to move to Release 8
- 110: Request to TSG#35 to move to Release 8
- 111: Request to TSG#35 to move to Release 8
- 112: Request to TSG#35 to move to Release 8
- 115: Request to TSG#35 to move to Release 8
- 116: Created to encompass the Rel7 Work Tasks shifted to Rel8
- 117: Created to encompass the Rel7 Work Tasks shifted to Rel8
- 118: Created to encompass the Rel7 Work Tasks shifted to Rel8
- 119: One CR at SA #35
- 120: End date to be determined when Rel-8 frozen.

| ID | WBS | Task | Type | Duration | Start | Finish | Complete | Remaining | Baseline start | Baseline finish | Baseline duration | Total slack | Constraint | Resources | Work | Actual work | Text1 | Text6 | Text8 | Text4 | Text5 | Text7 |
| --- | --- | --- | --- | --- | --- | --- | --- | --- | --- | --- | --- | --- | --- | --- | --- | --- | --- | --- | --- | --- | --- | --- |
| 121 | 26 | **Rel-8 Improvements of the Radio Interface** |  | 215d? | 2007-03-05 A | 2007-12-28 | 20% | 172.27d? | 2007-03-05 | 2007-12-28 | 215d? | 326d |  | RP | 7840h | 2056h | RInImp8 | Rel-8 | Claude |  |  |  |
| 122 | 26.1 | UMTS 1500 MHz |  | 140d? | 2007-03-05 A | 2007-09-14 | 50% | 70d? | 2007-03-05 | 2007-09-14 | 140d? | 401d | finish no earlier than 2007-09-14 | R4 | 1120h | 560h | RInImp8-UMTS1500 | Rel-8 | Claude | Takehiro Nakamura | NTT DoCoMo | TSG |
| 123 | 26.2 | UMTS 700 MHz |  | 215d? | 2007-03-05 A | 2007-12-28 | 20% | 172d? | 2007-03-05 | 2007-12-28 | 215d? | 326d | start no earlier than 2007-03-05 | R4 | 1720h | 344h | RInImp8-UMTS700 | Rel-8 | Claude | Tuomo Saynajakangas | Nokia | TSG |
| 124 | 26.3 | UMTS 2300 MHz |  | 215d? | 2007-03-05 | 2007-12-28 |  |  | 2007-03-05 | 2007-12-28 | 215d? | 326d | start no earlier than 2007-03-05 | R4 | 1720h |  | RInImp8-UMTS2300 | Rel-8 | Claude | Marc Grant | marc.grant@cingular.com | TSG |
| 125 | 26.4 | Further Improved Minimum Performance Requirements for HSDPA UE (FDD) - Two-Branch Interference Cancellation |  | 215d? | 2007-03-05 A | 2007-12-28 | 20% | 172d? | 2007-03-05 | 2007-12-28 | 215d? | 326d | finish no earlier than 2007-12-28 | R4 | 1720h | 344h | RInImp8-2BIC | Rel-8 | MCC_RAN | Marc Grant, Cingular | marc.grant@cingular.com |  |
| 126 | 27 | **Personal Network Management** |  | 971d? | 2005-07-11 A | 2009-03-30 | 44% | 548.22d? | 2005-07-11 | 2009-03-30 | 971d? | 0d |  | S1 | 22236.8h | 8583.26h | PNM | Rel-8 | Alain | Armin Toepfer, Vodafone | armin.toepfer@vodafone.com |  |
| 127 | 27.1 | Stage 1 of PNM |  | 276d? | 2005-07-11 A | 2006-07-31 | 85% | 41.4d? | 2005-07-11 | 2006-07-31 | 276d? | 695d | start no earlier than 2005-07-11 | S1 | 2208h | 1876.8h | PNM | Rel-8 | Alain |  |  |  |
| 128 | 27.2 | Deleted - Actual Requirements of PNM | milestone | 0d? | 2007-03-26 A | 2007-03-26 A | 100% |  | 2007-03-26 | 2009-03-30 | 526d? |  | finish no earlier than 2007-03-26 | C1 |  |  | PNM | Rel-8 |  | Yang Lu, |  |  |
| 129 | 27.3 | Stage 2 of PNM |  | 526d? | 2007-03-26 A | 2009-03-30 | 70% | 157.8d? | 2007-03-26 | 2009-03-30 | 526d? | 0d | finish no earlier than 2009-03-30 | C1 | 4208h | 2945.6h | PNM | Rel-8 |  | Yang Lu, |  |  |
| 130 | 27.4 | **Stage 3 of PNM** |  | 500d? | 2007-03-26 A | 2009-02-20 | 5% | 475d? | 2007-03-26 | 2008-03-26 | 263d? | 26d |  | C1 | 8115.2h | 405.76h | PNM | Rel-8 |  | Yang Lu, |  |  |
| 131 | 27.4.1 | CT1 aspects of PNM |  | 395d? | 2007-08-20 A | 2009-02-20 | 5% | 375.25d? | 2007-03-26 | 2008-03-26 | 263d? | 26d | finish no earlier than 2008-09-26 | C1 | 3160h | 158h | PNM | Rel-8 |  | Yang Lu, |  |  |
| 132 | 27.4.2 | CT4 aspects of PNM |  | 263d? | 2007-03-26 A | 2008-03-26 | 5% | 249.85d? | 2007-03-26 | 2008-03-26 | 263d? | 263d | start no earlier than 2007-03-26 | C4 | 2104h | 105.2h | PNM | Rel-8 |  | Yang Lu, |  |  |
| 133 | 28 | **Charging Management small Enhancements** |  | 420d? | 2006-05-08 A | 2007-12-14 | 35% | 273.55d? | 2006-05-08 | 2007-12-14 | 420d? | 336d |  | S5 | 7584h | 1505.47h | CH8 | Rel-8 | Adrian | Orange |  |  |
| 134 | 28.1 | Online charging correlation |  | 420d? | 2006-05-08 A | 2007-12-14 | 25% | 315d? | 2006-05-08 | 2007-12-14 | 420d? | 336d | finish no earlier than 2007-12-14 | S5 | 3360h | 840h |  | Rel-8 |  | Orange |  |  |
| 135 | 28.2 | SMS online charging |  | 118d? | 2007-04-02 A | 2007-09-12 | 70% | 35.4d? | 2007-04-02 | 2007-04-02 | 1d? | 403d | finish no earlier than 2007-09-12 | S5 | 944h | 660.8h |  | Rel-8 |  | Vodafone |  |  |
| 136 | 29 | **OSA Rel-8** |  | 336d? | 2007-08-23 | 2008-12-04 |  |  | 2007-08-23 | 2008-12-04 | 336d? | 82d |  | S1 | 5016h |  | OSA8 | Rel-8 | Alain | Orange |  | TSG |
| 137 | 29.1 | OSA Stage 1 - Service Requirements |  | 336d? | 2007-08-23 | 2008-12-04 |  |  | 2007-08-23 | 2008-12-04 | 336d? | 82d | finish no earlier than 2008-12-04 | S1 | 2688h |  | OSA8 | Rel-8 | Alain |  |  | TSG |
| 138 | 29.2 | OSA Stage 2/3 enhancements |  | 291d? | 2007-10-25 | 2008-12-04 |  |  | 2007-10-25 | 2008-12-04 | 291d? | 82d | finish no earlier than 2008-12-04 | C5 | 2328h |  | OSA8 | Rel-8 | Adrian | Orange |  |  |
| 139 | 30 | Combination of 64QAM and MIMO for HSDPA (FDD) |  | 201d? | 2007-06-04 | 2008-03-10 |  |  | 2007-06-04 | 2008-03-10 | 201d? | 275d | finish no earlier than 2008-03-10 | R1 | 1608h |  | RANimp-64QamMimoHsdpa | Rel-8 | MCC_RAN | Johan Bergman, Ericsson | Johan.Bergman@ericsson.com |  |
| 140 | 31 | Security Enhancements for IMS |  | 272d? | 2007-03-01 | 2008-03-14 |  |  | 2006-12-06 | 2007-12-20 | 272d? | 271d | finish no earlier than 2008-03-14 | S3 | 1608h |  | IMS-Sec | Rel-8 | Dioniso | Bengt Sahlin (Ericsson) |  |  |
| 141 | 32 | **Support of (G)MSC-S – (G)MSC-S Nc Interface based on the SIP-I protocol** |  | 266d? | 2007-09-14 A | 2008-09-19 | 5% | 252.7d? |  |  |  | 136d |  | C4 | 8512h | 425.6h | SIP_Nc | Rel-8 | Kimmo | David Hutton (Vodafone Group) | David.Hutton@VODAFONE.COM |  |
| 142 | 32.1 | SIP-I based circuit-switched core network; Stage 2 |  | 266d? | 2007-09-14 A | 2008-09-19 | 5% | 252.7d? |  |  |  | 136d | finish no earlier than 2008-09-19 | C4 | 2128h | 106.4h | SIP_Nc-St2 | Rel-8 | Kimmo |  |  |  |
| 143 | 32.2 | Application of SIP-I Protocols to Circuit Switched (CS) core network architecture; Stage 3 |  | 266d? | 2007-09-14 A | 2008-09-19 | 5% | 252.7d? |  |  |  | 136d | finish no earlier than 2008-09-19 | C4 | 2128h | 106.4h | SIP_Nc-St3 | Rel-8 | Kimmo |  |  |  |
| 144 | 32.3 | Interworking between the 3GPP CS domain with SIP-I as signalling protocol and other networks |  | 266d? | 2007-09-14 A | 2008-09-19 | 5% | 252.7d? |  |  |  | 136d | finish no earlier than 2008-09-19 | C3 | 2128h | 106.4h | SIP_Nc-IW | Rel-8 | Seung Don |  |  |  |
| 145 | 33 | IMS Stage-3 IETF Protocol Alignment |  | 316d? | 2007-06-22 A | 2008-09-05 | 10% | 284.4d? |  |  |  | 146d | start no earlier than 2007-06-22 | C1 | 2528h | 252.8h | IMSProtoc2 | Rel-8 | Andrijana | Keith Drage (Alcatel-Lucent) | drage@alcatel-lucent.com |  |
| 146 | 34 | New multicarrier BTS class |  | 126d? | 2007-08-31 | 2008-02-22 |  |  |  |  |  | 286d | finish no earlier than 2008-02-22 | G1 | 1008h |  | MCBTS | Rel-8 | Paolo | Thomas BITZER (Alcatel-Lucent) | thomas.bitzer@alcatel-lucent.de |  |
| 147 | 35 | MS Antenna Performance Evaluation Method and Requirements |  | 801d? | 2005-01-28 A | 2008-02-22 | 80% | 160.2d? |  |  |  | 286d | finish no earlier than 2008-02-22 | GP | 6408h | 5126.4h | APEMR | Rel-8 | Paolo | Ulf.Tegth (TeliaSonera) | Ulf.Tegth@teliasonera.com |  |
| 148 | 36 | U-TDOA Enhancement |  | 201d? | 2007-05-18 A | 2008-02-22 | 25% | 150.75d? |  |  |  | 286d | finish no earlier than 2008-02-22 | GP | 1608h | 402h | GUTEN | Rel-8 | Paolo | Ms. Terri L. Brooks, TruePosition, Inc. | terri.brooks@trueposition.com |  |

Notes:
- 122: Text3: TS25.101, TS25.104, TS25.133, TS25.141, TS25.331, TS25.942, TS25.306, TS25.307, TS34.121
- 123: Text3: TS25.101, TS25.104, TS25.133, TS25.141, TS25.331, TS25.942, TS25.306, TS25.307, TS34.121
- 124: Text3: TS25.101, TS25.104, TS25.133, TS25.141, TS25.331, TS25.942, TS25.306, TS25.307, TS34.121
- 126: Moved from FS section Feb 06. SP-33: Create new section to capture the PNM stage 2 aspects and identify any impacts to existing stage 2 specifications. S2 added as secondary responsibility
- 127: Moved from FS section Feb 06: SP-33: Create new section to capture the PNM stage 2 aspects and identify any impacts to existing stage 2 specifications. / Text3: 22.259, 23.818
- 129: Text3: 23.259
- 130: Moved from FS section Feb 06: SP-33: Create new section to capture the PNM stage 2 aspects and identify any impacts to existing stage 2 specifications.
- 131: Text3: 24.229, 24.259
- 132: Text3: 23.008, 23.018, 29.002, 29.328, 29.329
- 133: Text3: 32.2xy
- 134: WID approved SA#35 / Text3: 32.240, 32.296
- 135: Text3: TS 32.274, CR 32.240 / 299/ 298
- 137: az: WID URL corrected / Text3: 22.127
- 138: CT#34: WID updated. Completion 12/06 =>03/07 / Text3: 23.198, 29.198/9
- 139: Text3: 25.308,25.211,25.212,25.213,25.306,25.331,25.433,25.435,25.423,25.425,25.101,25.104,25.141
- 140: WID approved at SP-36 / Text3: 33.203, 33.828, 33.803
- 142: Text3: TS 23.xyz
- 143: Text3: TS 29.xyz
- 144: Text3: TS 29.xyz
- 145: Text3: 23.218, 24.229
- 146: Text3: 45.005, 45.050, 51.021
- 147: Moved from Rel7 / Text3: 25.914, 25.144, 45.005
- 148: Moved from Rel7 / Text3: 43.059, 45.008, 48.071

| ID | WBS | Task | Duration | Start | Finish | Complete | Remaining | Baseline start | Baseline finish | Baseline duration | Total slack | Constraint | Resources | Work | Actual work | Text1 | Text3 | Text4 | Text5 | Text6 | Text8 | Text12 | Text7 |
| --- | --- | --- | --- | --- | --- | --- | --- | --- | --- | --- | --- | --- | --- | --- | --- | --- | --- | --- | --- | --- | --- | --- | --- |
| 149 | 37 | **GAN Enhancements** | 261d? | 2007-08-31 | 2008-08-29 |  |  |  |  |  | 151d |  | GP | 5184h |  | GANENH | 43.318, 44.318, 51.010 | Mohammed Versi, T-Mobile USA Inc. | mohammed.versi@t-mobile.com | Rel-8 | Paolo |  |  |
| 150 | 37.1 | Update to GAN specifications | 126d? | 2007-08-31 | 2008-02-22 |  |  |  |  |  | 286d | finish no earlier than 2008-02-22 | GP | 1008h |  | GANENH-SPEC | 43.318, 44.318 | Mohammed Versi, T-Mobile USA Inc. | mohammed.versi@t-mobile.com | Rel-8 | Paolo, Gert |  |  |
| 151 | 37.2 | Update TS 51.010 Mobile Station (MS) Conformance Specification for GAN Enhancements | 261d? | 2007-08-31 | 2008-08-29 |  |  |  |  |  | 151d | finish no earlier than 2008-08-29 | GP | 2088h |  | GANENH-MStest | 51.010 | Mohammed Versi, T-Mobile USA Inc. | mohammed.versi@t-mobile.com | Rel-8 | Stoyan |  |  |
| 152 | 38 | (Small) Technical Enhancements and Improvements for Rel-8 | 400d? | 2007-01-01 | 2008-07-11 |  |  | 2007-01-01 | 2008-07-11 | 400d? | 186d | start no earlier than 2007-01-01 | All | 3200h |  | TEI8 |  |  |  | Rel-8 |  |  |  |
| 153 | 39 | Delete - was a Rel7 item - LCS for 3GPP Interworking WLAN | 245d? | 2006-10-23 | 2007-09-28 |  |  | 2006-10-23 | 2007-09-28 | 245d? | 391d | finish no earlier than 2007-09-28 | S2 | 1960h |  | LCS4_IWLAN | 23.234, 23.271, 23.167 | Donghee Shim (LG Electronics Inc.) | dhshim@lge.com | Rel-8 | Maurice | S2-56 |  |
| 154 | 40 | Rel-8 Feasibility Studies | 1d? | 2000-01-03 | 2000-01-03 |  |  | 2000-01-03 | 2000-01-03 | 1d? | 2410d |  | CT;RAN;SA | 8h |  |  |  |  |  | Rel-8 |  |  |  |
| 155 | 41 | Study on Facilitating Machine to Machine Communication in GSM and UMTS (M2M) | 161d? | 2005-11-04 A | 2006-06-16 | 90% | 16.1d? | 2005-11-04 | 2006-06-16 | 161d? | 726d | finish no earlier than 2006-06-16 | S1 | 1288h | 1159.2h | M2M | 22.868 | Juergen Merkel, Siemens AG |  | Rel-8 | Alain |  |  |
| 156 | 42 | FS on Network Composition | 211d? | 2005-12-07 A | 2006-09-27 | 90% | 21.1d? | 2005-12-07 | 2006-09-27 | 211d? | 653d | finish no earlier than 2006-09-27 | S1 | 1688h | 1519.2h | NetComp | 22.980 | Joerg Swetina (Siemens) | joerg.swetina@siemens.com | Rel-8 | Alain |  |  |
| 157 | 43 | Study on Charging Aspects of 3GPP System Evolution | 179d? | 2007-04-02 A | 2007-12-06 | 50% | 89.5d? | 2007-04-02 | 2007-12-06 | 179d? | 342d | finish no earlier than 2007-12-06 | S5 | 1432h | 716h | FSSAEcharg | TR 32.820 | Nokia Siemens Networks |  | Rel-8 |  | SP-32 |  |
| 158 | 44 | **All-IP Network (AIPN)** | 448d? | 2004-06-28 A | 2006-03-15 A | 100% |  | 2004-06-28 | 2006-03-15 | 448d? |  |  | S1 | 8672h | 8672h | AIPN | 22.978 | Chris Sachno (NTT DoCoMo) | c.masyu@nttdocomo.co.jp | Rel-8 | Alain |  | TSG |
| 159 | 44.1 | All-IP Network Feasibility Study | 188d? | 2004-06-28 A | 2005-03-16 A | 100% |  | 2004-06-28 | 2005-03-16 | 188d? |  | start no earlier than 2004-06-28 | S1 | 1504h | 1504h | AIPFS | 22.978 | Chris Sachno (NTT DoCoMo) | c.masyu@nttdocomo.co.jp | Rel-8 | Alain |  | TSG |
| 160 | 44.2 | Stage1 | 448d? | 2004-06-28 A | 2006-03-15 A | 100% |  | 2004-06-28 | 2006-03-15 | 448d? |  | finish no earlier than 2006-03-15 | S1 | 3584h | 3584h | AIPN | 22.258 | Chris Sachno (NTT DoCoMo) | c.masyu@nttdocomo.co.jp | Rel-8 | Alain |  | TSG |
| 161 | 45 | Study on Stage 2 aspects of IMS Service Brokering | 455d? | 2006-06-19 A | 2008-03-14 | 50% | 227.5d? | 2006-06-19 | 2007-12-01 | 380d? | 271d | finish no earlier than 2008-03-14 | S2 | 3640h | 1820h | ISB_ST2_SDY | 23.810 | Raquel Morera (Telcordia); F. Joe Lin (Telcordia) | raquel@research.telcordia.com | Rel-8 | Maurice |  |  |
| 162 | 46 | Study of Requirements of IMS Multimedia Conferencing | 205d? | 2006-06-08 A | 2007-03-21 | 70% | 61.5d? | 2006-06-08 | 2007-03-21 | 205d? | 528d | finish no earlier than 2007-03-21 | S1 | 1640h | 1148h | SI-IMSconf | 22.948 | Zheng Jianping (China Mobile ) | zhengjianping@chinamobile.com | Rel-8 | Alain |  |  |
| 163 | 47 | Study on support of a Public Warning System | 205d? | 2006-06-08 A | 2007-03-21 | 70% | 61.5d? | 2006-06-08 | 2007-03-21 | 205d? | 528d | start no earlier than 2006-06-08 | S1 | 1640h | 1148h | PWS-SI | 22.968 | Mark Young (T-mobile) | mark.younge@t-mobile.com | Rel-8 | Alain |  |  |
| 164 | 48 | Study on Protection against SMS and MMS spam | 402d? | 2006-06-08 A | 2007-12-21 | 10% | 361.8d? | 2006-06-08 | 2007-12-21 | 402d? | 331d | finish no earlier than 2007-12-21 | S3 | 3216h | 321.6h | CPSMal | 33.9xx | Eric Gauthier (Orange SA) | eric.gauthier@orange.ch | Rel-8 | Dioniso |  |  |
| 165 | 49 | Study of VCC support for Emergency Calls | 532d? | 2006-06-08 A | 2008-06-20 | 20% | 425.6d? | 2006-06-08 | 2007-12-01 | 387d? | 201d | finish no earlier than 2008-06-20 | S2 | 4256h | 851.2h | FSVCCEm | 23.826 | Ricky Kaura, Nortel |  | Rel-8 | Maurice |  |  |
| 166 | 50 | Study on Centralised IMS Service Control | 290d? | 2006-10-23 A | 2007-12-01 | 75% | 72.5d? | 2006-10-23 | 2007-12-01 | 290d? | 346d | finish no earlier than 2007-12-01 | S2 | 2320h | 1740h | IMS_CSC | 23.892 | Andy Bennett (Alcatel-Lucent) | andybennett@Alcatel-Lucent.com | Rel-8 | Maurice |  |  |
| 167 | 51 | Study on IMS utilizing multicast bearer services | 444d? | 2006-03-22 A | 2007-12-03 | 80% | 88.8d? | 2006-03-22 | 2007-09-28 | 398d? | 345d | finish no earlier than 2007-12-03 | S2 | 3552h | 2841.6h | FS-MLTICAST-IMS | 23.847 | Fiona Zhu (Siemens AG) |  | Rel-8 | Maurice |  |  |
| 168 | 52 | Study on Paging Permission with Access Control | 256d? | 2006-09-28 A | 2007-09-20 | 80% | 51.2d? | 2006-09-28 | 2007-09-20 | 256d? | 397d | finish no earlier than 2007-09-20 | S1 | 2048h | 1638.4h | PPAC | 22.908 | Katsuhiro Noguchi (NTT DoCoMo Inc.) | noguchi@nttdocomo.co.jp | Rel-8 | Alain |  |  |
| 169 | 53 | Study on Non 3GPP access NSP | 207d? | 2006-12-06 A | 2007-09-20 | 40% | 124.2d? | 2006-12-06 | 2007-09-20 | 207d? | 397d | start no earlier than 2006-12-06 | S1 | 1656h | 662.4h | N3GtoNSP | 22.812 | Chris Friel (O2) | chris.friel@o2.com | Rel-8 | Alain |  |  |
| 170 | 54 | Study on Value Added Services for Short Message Service | 263d? | 2006-12-06 A | 2007-12-07 | 60% | 105.2d? | 2006-12-06 | 2007-12-07 | 263d? | 341d | finish no earlier than 2007-12-07 | S1 | 2104h | 1262.4h | VAS4SMS | 22.xxx | Wu Bin (China Mobile Communications Corporation) | wubin@chinamobile.com | Rel-8 | Alain |  |  |
| 171 | 55 | Study on Requirements for seamless roaming and service continuity between mobile and WLAN networks | 262d? | 2006-12-06 A | 2007-12-06 | 20% | 209.6d? | 2006-12-06 | 2007-12-06 | 262d? | 342d | finish no earlier than 2007-12-06 | S1 | 2096h | 419.2h | SMLSWLAN | 22.937 | Mike Meyerstein (BT) | mike.meyerstein@bt.com | Rel-8 | Alain |  |  |
| 172 | 56 | Feasibility Study of Mobility between 3GPP-WLAN Interworking and 3GPP Systems | 129d? | 2007-03-20 A | 2007-09-14 A | 100% |  | 2007-03-20 | 2007-09-14 | 129d? |  | start no earlier than 2007-03-20 | S2 | 1032h | 1032h | SM3GWLAN | 23.837 | Orange | orange | Rel-8 | Maurice |  |  |

Notes:
- 153: New WID approved SP-34. Supporting companies: Telcordia, Samsung, Qualcomm, BT, LG Electronics, Cingular, Alcatel-Lucent. No scheduled end date!
- 157: WID approved SA#35
- 161: Study approved SA#32
- 164: Formerly called "Consumer protection against spam and malware"
- 165: Rapporteur update S2#59
- 166: Approved at SP#33
- 171: Revised at SA#36
- 172: Rapporteur name to be provided. Supporting companies: T-Mobile, Orange, China Mobile, Telenor, Alcatel-Lucent, Azaire Networks, Airvana. TR will be stopped when Spec WID is approved

| ID | WBS | Task | Duration | Start | Finish | Complete | Remaining | Baseline start | Baseline finish | Baseline duration | Total slack | Constraint | Resources | Work | Actual work | Text1 | Text6 | Text8 | Text3 | Text4 | Text12 | Text5 | Text7 |
| --- | --- | --- | --- | --- | --- | --- | --- | --- | --- | --- | --- | --- | --- | --- | --- | --- | --- | --- | --- | --- | --- | --- | --- |
| 173 | 57 | **OAM&P Rel-8 Studies** | 725d? | 2005-09-02 A | 2008-06-12 | 55% | 328.8d? | 2005-09-02 | 2008-06-12 | 725d? | 207d |  | S5 | 19225.6h | 8708.8h | OAM8-Study | Rel-8 | Adrian |  |  |  |  |  |
| 174 | 57.1 | Study of Element Operations Systems Function (EOSF) definition | 596d? | 2005-09-02 A | 2007-12-14 | 30% | 417.2d? | 2005-09-02 | 2007-12-14 | 596d? | 336d | finish no earlier than 2007-12-14 | S5 | 4768h | 1430.4h |  | Rel-8 |  | TR 32.819 | China Mobile | SP-32 |  |  |
| 175 | 57.2 | Study on SA5 MTOSI XML Harmonization | 418d? | 2006-05-10 A | 2007-12-14 A | 100% |  | 2006-05-10 | 2007-12-14 | 418d? |  | finish no earlier than 2007-12-14 | S5 | 3344h | 3344h |  | Rel-8 |  | TR 32.818 | Nortel | SP-32 |  |  |
| 176 | 57.3 | Study of Common Profile Storage (CPS) Framework of User Data for network services and management | 244d? | 2006-07-03 A | 2007-06-07 A | 100% |  | 2006-07-03 | 2007-06-07 | 244d? |  | finish no earlier than 2007-06-07 | S5 | 1952h | 1952h |  | Rel-8 |  | TR 32.808 | T-Mobile |  |  |  |
| 177 | 57.4 | Study of Management for LTE and SAE | 202d? | 2006-12-07 A | 2007-09-14 | 70% | 60.6d? | 2006-12-07 | 2007-09-14 | 202d? | 401d | finish no earlier than 2007-09-14 | S5 | 1616h | 1131.2h |  | Rel-8 |  | TR 32.816 | Ericsson |  |  |  |
| 178 | 57.5 | Study of System Maintenance by Itf-N | 266d? | 2007-06-07 A | 2008-06-12 | 20% | 212.8d? | 2007-06-07 | 2008-06-12 | 266d? | 207d | finish no earlier than 2008-06-12 | S5 | 2128h | 425.6h |  | Rel-8 |  | TR 32.822 | ZTE |  |  |  |
| 179 | 57.6 | Study of Self-Organizing Networks (SON) related OAM interfaces for Home NodeB | 266d? | 2007-06-07 A | 2008-06-12 | 20% | 212.8d? | 2007-06-07 | 2008-06-12 | 266d? | 207d | finish no earlier than 2008-06-12 | S5 | 2128h | 425.6h |  | Rel-8 |  | TR 32.821 | Huawei |  |  |  |
| 180 | 58 | SI on AS-MRFC media server control protocol | 318d? | 2006-03-22 A | 2007-06-08 | 77% | 73.14d? | 2006-03-22 | 2007-06-08 | 318d? | 471d | finish no earlier than 2007-06-08 | C1 | 2544h | 1958.88h | MRFC | Rel-8 |  | New TR 24.880 | Mark Syrett (Hewlett-Packard) |  |  |  |
| 181 | 59 | FS Restoration Procedures | 180d? | 2007-03-26 A | 2007-11-30 | 15% | 153d? | 2007-03-26 | 2007-11-30 | 180d? | 346d | start no earlier than 2007-03-26 | C4 | 1440h | 216h | FSIMS8_RP | Rel-8 | Kimmo | TR 23.820 | German Blanco (Ericsson) |  | german.blanco@ericsson.com |  |
| 182 | 60 | FS on 3G Home NodeB/eNodeB | 210d? | 2007-03-05 A | 2007-12-21 | 10% | 189d? | 2007-03-05 | 2007-12-21 | 210d? | 331d | finish no earlier than 2007-12-21 | R4 | 1680h | 168h | RANFS-HNBeNB | Rel-8 | Claude |  | Howard Thomas (Motorola) |  |  |  |
| 183 | 61 | FS on Multimedia Session Continuity | 232d? | 2007-04-26 A | 2008-03-14 | 20% | 185.6d? | 2007-04-26 | 2007-12-03 | 158d? | 271d | finish no earlier than 2008-03-14 | S2 | 1856h | 371.2h | MMSC_FS | Rel-8 | Maurice | 23.893 | Jaeseung Song (LG Electronics) |  |  |  |
| 184 | 62 | FS on CS Domain Services over evolved PS access | 233d? | 2007-04-25 A | 2008-03-14 | 50% | 116.5d? | 2007-04-25 | 2008-07-25 | 328d? | 271d | finish no earlier than 2008-03-14 | S2 | 1864h | 932h | FS_CSoPS | Rel-8 | Maurice | 23.879 | Sabine Demel (T-Mobile International) |  | Sabine(dot)Demel(at)T-Mobile(dot)at |  |
| 185 | 63 | FS on Transferring of emergency call data – in-band modem solution | 466d? | 2006-12-07 A | 2008-09-18 | 60% | 186.4d? | 2006-12-07 | 2007-06-07 | 131d? | 137d | finish no earlier than 2008-09-18 | S4 | 3728h | 2236.8h | eCALLIBMS | Rel-8 | Paolo | 26.967 | Leon Hong, Airbiquity |  | lhong@airbiquity.com |  |
| 186 | 64 | FS on Improved network controlled mobility between LTE and 3GPP2/mobile WiMAX radio technologies | 131d? | 2007-06-04 | 2007-12-03 |  |  | 2007-06-04 | 2007-12-03 | 131d? | 345d | finish no earlier than 2007-12-03 | R2 | 1048h |  | RANFS-LTEmob | Rel-8 |  | 25.9xx |  |  |  |  |
| 187 | 65 | FS on IMS Application Server Service Data Descriptions for AS interoperability | 131d? | 2007-09-14 A | 2008-03-14 | 5% | 124.45d? |  |  |  | 271d | finish no earlier than 2008-03-14 | C4 | 1048h | 52.4h | FSIMS8_ASIO | Rel-8 | Kimmo | TR 29.9yz | Nigel Berry (Alcatel-Lucent |  | nhberry@ALCATEL-LUCENT.COM |  |
| 188 | 66 | FS on CAT solution for voice and video call in CS domain | 131d? | 2007-09-14 A | 2008-03-14 | 5% | 124.45d? |  |  |  | 271d | finish no earlier than 2008-03-14 | C4 | 1048h | 52.4h | FSCusAlert-St3 | Rel-8 | Kimmo | TR 29.9yz | Zhang Hao (China Mobile) |  | zhanghao@chinamobile.com |  |
| 189 | 67 | **(FS on) 3GPP System Architecture Evolution** | 736d? | 2004-12-03 A | 2007-09-28 | 77% | 166.71d? | 2004-12-03 | 2007-09-28 | 736d? | 391d |  | S2 | 11864h | 9176.73h | SAE | Rel-8 | Dioniso |  |  |  |  | TSG |
| 190 | 67.1 | Stage 2 Interim conclusion for RAN Work to start | 211d? | 2004-12-03 A | 2005-09-23 A | 100% |  | 2004-12-03 | 2005-09-23 | 211d? |  | finish no earlier than 2005-09-23 | S2 | 1688h | 1688h |  | Rel-8 |  | 23.882 |  |  |  |  |
| 191 | 67.2 | Stage 2 Feasibility study on 3GPP architectural development | 450d? | 2006-01-09 A | 2007-09-28 | 71% | 130.5d? | 2006-01-09 | 2007-09-28 | 450d? | 391d | finish no earlier than 2007-09-28 | S2 | 3600h | 2556h |  | Rel-8 | Maurice | 23.882 | Chris Pudney |  |  |  |
| 192 | 67.3 | Security study for Inter-access mobility between non 3GPP and 3GPP system | 86d? | 2006-02-03 A | 2006-06-02 | 55% | 38.7d? | 2006-02-03 | 2006-06-02 | 86d? | 736d | start no earlier than 2006-02-03 | S3 | 688h | 378.4h | SAE-Sec | Rel-8 | Dioniso | 23.882, 33.821, 33.922 | Dajiang Zhang (Nokia) |  | dajiang.zhang@NOKIA.COM |  |
| 193 | 68 | DELETE - Study on GAN Enhancements | 206d? | 2006-11-17 A | 2007-08-31 A | 100% |  | 2006-11-17 | 2007-08-31 | 206d? |  | start no earlier than 2006-11-17 | GP | 1648h | 1648h | EGAN | Rel-7 | Paolo | 43.902 | Janne Linkola (T-Mobile) |  | janne.linkola@t-mobile.com |  |

Notes:
- 173: Created to encompass the Rel7 Work Tasks shifted to Rel8
- 174: Request to TSG#35 to move to Release 8
- 175: Request to TSG#35 to move to Release 8
- 176: Submit Exception Sheet for TSG#35 Approval
- 177: 12/2006 SA#34 WID approved
- 183: SID approved at SP-36
- 184: SID approved at SP-36
- 185: Moved from Rel7
- 189: Moved from Rel-7
- 190: Moved from Rel-7
- 191: Moved from Rel-7
- 192: Moved from Rel-7
- 193: Completed for Rel7
